# KAGRA16-Cryostat-Construction-plan-140914-Rev02-2007

Schedule from MS Project, 2014-04-01 to 2015-03-19.

## Calendars

- KAGRA: Mon-Sat 08:00-12:00, 13:00-17:00; Sun off. Exceptions (off unless hours are given): 2014-04-29 to 2014-05-05 (GW), 2014-07-21 (休), 2014-08-14 to 2014-08-16 (盆), 2014-09-15 (休), 2014-09-23 (休), 2014-10-13 (休), 2014-11-03 08:00-12:00, 13:00-17:00, 2014-11-24 08:00-12:00, 13:00-17:00, 2014-12-29 to 2015-01-03 (正月), 2015-01-12 08:00-12:00, 13:00-17:00.
- 24時間体制: Mon-Sun 00:00-24:00. Exceptions (off unless hours are given): 2014-04-01 to 2015-06-30 08:00-12:00, 13:00-17:00 (夜).

## Resources

| Resource |
| --- |
| X-土木班 |
| X-測量・墨出し班 |
| X-ダクト据付班（4名） |
| X-架台搬入班（2名） |
| X-架台据付班（3名×2班） |
| X-ダクト締結班（3名×2班） |
| X-基礎(4名) |
| X-運搬据付(5名) |
| X-配線(10名) |
| X-取付(3名) |
| X-低圧配線(8名) |
| X-Tr(3名) |
| X-照明(6名) |
| X-光（5名) |
| Y-ダクト据付班（4名） |
| Y-架台搬入班（2名） |
| Y-架台据付班（3名×2班） |
| Y-ダクト締結班（3名×2班） |
| Y-基礎(4名) |
| Y-運搬据付(5名) |
| Y-配線(10名) |
| Y-取付(3名) |
| Y-低圧配線(8名) |
| Y-Tr(3名) |
| Y-照明(6名) |
| Y-光（5名) |
| Y-土木班 |
| Y-測量・墨出し班 |
| 仮置き |
| クライオ組立班(4名体制) |
| クライオ組立班(3名体制) |
| クライオ組立班(2名体制) |
| カニクレーン班（オペレータ1名+玉掛け1名） |
| リーク試験担当（ICRR担当2名） |
| １８３ |
| 東芝技術指導(1名体制) |
| 東芝技術指導(2名体制) |
| 東芝技術指導初日のみ |
| ジェック東理社技術指導(1名体制) |
| 中央室C2名 |
| 中央室クレーン(作業員２名) |
| ICRR立ち会い１名 |
| 中央室クレーン(作業員２名作業日１日) |

## Schedule

| ID | WBS | Task | Type | Duration | Start | Finish | Predecessors | Total slack | Free slack | Constraint | Resources | Work |
| --- | --- | --- | --- | --- | --- | --- | --- | --- | --- | --- | --- | --- |
| 1 | 1 | 巣之内物品仮置き |  | 3d | 2014-08-09 | 2014-08-12 | 93, 34SS-3d | 66d | 0d |  | 仮置き | 24h |
| 2 | 2 | 古川物品事前搬入 |  | 6d | 2014-08-13 | 2014-08-22 | 1 | 66d | 0d |  | 仮置き | 48h |
| 3 | 3 | 古川物品整理、仮置き |  | 4d | 2014-08-23 | 2014-08-27 | 2 | 166d |  |  | 仮置き | 32h |
| 4 | 4 | 高圧ｹｰﾌﾞﾙ(鋼帯がい装）納入 | milestone | 1d | 2014-06-09 | 2014-06-09 |  | 230d |  | start no earlier than 2014-06-09 |  |  |
| 5 | 5 | 高圧ケーブル（鋼帯がい装）配線、受電？ |  | 13d | 2014-09-01 | 2014-09-16 |  | 150d |  | start no earlier than 2014-09-01 |  |  |
| 6 | 6 | **X-機器設置工事** |  | 88d? | 2014-09-16 | 2015-01-05 |  | 11d |  |  |  | 1800h |
| 7 | 6.1 | X- 墨出し1（end） |  | 2d | 2014-09-16 | 2014-09-17 | 90, 111 | 11d | 0d |  | X-測量・墨出し班 | 16h |
| 8 | 6.2 | コア抜き、カッター |  | 9d | 2014-09-18 | 2014-09-29 | 7 | 11d | 0d |  |  |  |
| 9 | 6.3 | X- 土間仕上げ1（end） |  | 6d | 2014-09-30 | 2014-10-06 | 8 | 11d | 0d |  | X-土木班 | 48h |
| 10 | 6.4 | X- 墨出し2（arm） |  | 30d | 2014-09-18 | 2014-10-24 | 7 | 119d |  |  | X-測量・墨出し班 | 240h |
| 11 | 6.5 | 搬出準備 |  | 1d? | 2014-10-06 | 2014-10-06 | 12SS-1d | 134d |  |  |  |  |
| 12 | 6.6 | X- End側防振(EXV)入設置 |  | 1d | 2014-10-07 | 2014-10-07 | 9 | 11d | 0d |  | X-ダクト据付班（4名） | 8h |
| 13 | 6.7 | X- End側クライオ搬(EXC)入設置 |  | 3d | 2014-10-08 | 2014-10-10 | 12 | 11d | 0d |  | X-ダクト据付班（4名） | 24h |
| 14 | 6.8 | EXA、GV設置 |  | 3d | 2014-10-11 | 2014-10-15 | 13 | 11d | 0d |  | X-ダクト据付班（4名） | 24h |
| 15 | 6.9 | X- 架台搬入 |  | 60d | 2014-10-16 | 2014-12-24 | 25SS+3d, 14 | 11d | 0d |  | X-架台搬入班（2名） | 480h |
| 16 | 6.10 | X- 架台据付 |  | 60d | 2014-10-18 | 2014-12-26 | 15SS+2d | 11d | 0d |  | X-架台据付班（3名×2班） | 480h |
| 17 | 6.11 | X- ダクト搬入・設置 |  | 60d | 2014-10-21 | 2015-01-05 | 16SS+2d | 11d | 0d |  | X-ダクト据付班（4名） | 480h |
| 18 | 7 | **X-ダクト締結工事** |  | 118d | 2014-10-27 | 2015-03-19 |  | 0d |  |  |  | 944h |
| 19 | 7.1 | X- ダクト締結 |  | 118d | 2014-10-27 | 2015-03-19 |  | 0d |  | start no earlier than 2014-10-27 | X-ダクト締結班（3名×2班） | 944h |
| 20 | 8 | **X-アームトンネル電気工事** |  | 42d | 2014-09-16 | 2014-11-05 |  | 12d |  |  |  | 416h |
| 21 | 8.1 | X- 高圧受電盤設置(2基) |  | 2d | 2014-09-16 | 2014-09-17 | 85, 111, 90 | 12d | 0d |  | X-運搬据付(5名) | 16h |
| 22 | 8.2 | X- 高圧ケーブル（CET）配線 |  | 10d | 2014-09-18 | 2014-09-30 | 21 | 12d | 0d |  | X-配線(10名) | 80h |
| 23 | 8.3 | X- 動力配線 |  | 10d | 2014-09-25 | 2014-10-06 | 22SS+5d | 12d | 0d |  | X-低圧配線(8名) | 80h |
| 24 | 8.4 | X- 光ケーブル配線 |  | 3d | 2014-10-07 | 2014-10-09 | 23 | 12d | 0d |  | X-光（5名) | 24h |
| 25 | 8.5 | X- 実験盤、手元開閉器、光BOX設置 |  | 10d | 2014-10-10 | 2014-10-22 | 24 | 12d | 0d |  | X-取付(3名) | 80h |
| 26 | 8.6 | X- スコットトランス設置 |  | 5d | 2014-10-23 | 2014-10-28 | 25 | 116d |  |  | X-Tr(3名) | 40h |
| 27 | 8.7 | X- 照明配線 |  | 12d | 2014-10-23 | 2014-11-05 | 25 | 109d |  |  | X-照明(6名) | 96h |

| ID | WBS | Task | Duration | Start | Finish | Predecessors | Total slack | Free slack | Constraint | Resources | Work |
| --- | --- | --- | --- | --- | --- | --- | --- | --- | --- | --- | --- |
| 28 | 9 | **Y-機器設置工事** | 123d? | 2014-07-14 | 2014-12-11 |  | 74d |  |  |  | 1880h |
| 29 | 9.1 | Y-墨出し1（end） | 2d | 2014-07-28 | 2014-07-29 | 91 | 63d | 0d | start no earlier than 2014-07-28 | Y-測量・墨出し班 | 16h |
| 30 | 9.2 | コア抜き、カッター | 10d | 2014-07-30 | 2014-08-09 | 29 | 63d | 0d |  |  |  |
| 31 | 9.3 | Y-土間仕上げ1（end） | 2d | 2014-08-11 | 2014-08-12 | 30 | 63d | 0d |  | Y-土木班 | 16h |
| 32 | 9.4 | Y-墨出し2（arm） | 31d | 2014-07-14 | 2014-08-22 |  | 170d |  | start no earlier than 2014-07-14 | Y-測量・墨出し班 | 248h |
| 33 | 9.5 | 搬出準備 | 1d? | 2014-08-12 | 2014-08-12 | 34SS-1d | 176d |  |  |  |  |
| 34 | 9.6 | Y-End側防振(EYV)搬入設置 | 2d | 2014-08-13 | 2014-08-18 | 83, 82, 31 | 63d | 0d |  | Y-ダクト据付班（4名） | 16h |
| 35 | 9.7 | Y-End側クライオ(EYC)搬入設置 | 5d | 2014-08-19 | 2014-08-23 | 34 | 63d | 0d |  | Y-ダクト据付班（4名） | 40h |
| 36 | 9.8 | EYA、GV設置 | 2d | 2014-09-10 | 2014-09-11 | 35 | 49d | 0d | start no earlier than 2014-09-10 | Y-ダクト据付班（4名） | 16h |
| 37 | 9.9 | Y-架台搬入 | 60d | 2014-09-12 | 2014-11-24 | 2, 36, 45 | 49d | 0d |  | Y-架台搬入班（2名） | 480h |
| 38 | 9.10 | Y-架台据付 | 60d | 2014-09-16 | 2014-11-26 | 37SS+2d | 49d | 0d |  | Y-架台据付班（3名×2班） | 480h |
| 39 | 9.11 | Y-ダクト搬入・設置 | 71d | 2014-09-18 | 2014-12-11 | 38SS+2d | 49d | 0d |  | Y-ダクト据付班（4名） | 568h |
| 40 | 10 | **Y-ダクト締結工事** | 141d | 2014-09-29 | 2015-03-19 |  | 0d |  |  |  | 1128h |
| 41 | 10.1 | Y-ダクト締結 | 141d | 2014-09-29 | 2015-03-19 |  | 0d |  | start no earlier than 2014-09-29 | Y-ダクト締結班（3名×2班） | 1128h |
| 42 | 11 | **Y-アームトンネル電気工事** | 40d | 2014-07-30 | 2014-09-18 |  | 54d |  |  |  | 528h |
| 43 | 11.1 | Y-高圧受電盤設置(2基) | 2d | 2014-08-12 | 2014-08-13 | 86, 115 | 81d |  | start no earlier than 2014-08-12 | Y-運搬据付(5名) | 16h |
| 44 | 11.2 | Y-高圧ケーブル（CET）配線 | 10d | 2014-07-30 | 2014-08-09 |  | 84d |  | start no earlier than 2014-07-30 | Y-配線(10名) | 80h |
| 45 | 11.3 | Y-動力配線 | 12d | 2014-08-18 | 2014-08-30 |  | 59d | 10d | start no earlier than 2014-08-18 | Y-低圧配線(8名) | 96h |
| 46 | 11.4 | Y-光ケーブル配線 | 3d | 2014-09-16 | 2014-09-18 |  | 54d |  | start no earlier than 2014-09-16 | Y-光（5名) | 24h |
| 47 | 11.5 | Y-実験盤、手元開閉器、光BOX設置 | 15d | 2014-08-06 | 2014-08-26 |  | 73d |  | start no earlier than 2014-08-06 | Y-取付(3名) | 120h |
| 48 | 11.6 | Y-スコットトランス設置 | 12d | 2014-08-06 | 2014-08-22 |  | 76d |  | start no earlier than 2014-08-06 | Y-Tr(3名) | 96h |
| 49 | 11.7 | Y-照明配線 | 12d | 2014-08-18 | 2014-08-30 |  | 69d |  | start no earlier than 2014-08-18 | Y-照明(6名) | 96h |
| 50 | 12 | **（先行分）中央実験室機器設置** | 27d | 2014-07-24 | 2014-08-27 |  | 166d |  |  |  | 80h |
| 51 | 12.1 | 墨出し | 1d | 2014-07-24 | 2014-07-24 | 88, 93, 106, 107 | 175d | 0d |  | X-測量・墨出し班 | 8h |
| 52 | 12.2 | コア抜き、カッター | 8d | 2014-07-25 | 2014-08-02 | 51 | 175d | 0d |  |  |  |
| 53 | 12.3 | 土間仕上げ | 6d | 2014-08-04 | 2014-08-09 | 52 | 175d | 9d |  | X-土木班 | 48h |
| 54 | 12.4 | MCE、MCF、IFI、IMM、GVmc設置 | 3d | 2014-08-25 | 2014-08-27 | 83, 53, 35 | 166d |  |  | X-ダクト据付班（4名） | 24h |

| ID | WBS | Task | Duration | Start | Finish | Predecessors | Total slack | Free slack | Constraint | Resources | Work |
| --- | --- | --- | --- | --- | --- | --- | --- | --- | --- | --- | --- |
| 55 | 13 | **中央実験室機器設置** | 67d? | 2014-12-12 | 2015-03-06 |  | 11d |  |  |  | 368h |
| 56 | 13.1 | （PRM,PR3,IYA,IYC,Gvitmy）墨出し | 2d | 2014-12-12 | 2014-12-13 | 39, 92 | 49d | 0d |  | Y-測量・墨出し班 | 16h |
| 57 | 13.2 | コア抜き、カッター | 9d | 2014-12-15 | 2014-12-24 | 56 | 49d | 0d |  |  |  |
| 58 | 13.3 | 土間仕上げ（PRM,PR3,IYA,IYC,Gvitmy） | 10d | 2014-12-25 | 2015-01-12 | 57 | 49d | 0d |  | Y-土木班 | 80h |
| 59 | 13.4 | 搬出準備 | 1d? | 2015-01-12 | 2015-01-12 | 60SS-1d | 57d |  |  |  |  |
| 60 | 13.5 | （IYV）搬入設置 | 1d | 2015-01-13 | 2015-01-13 | 58 | 49d | 0d |  | Y-ダクト据付班（4名） | 8h |
| 61 | 13.6 | （IYA,IYC,GVitmy）搬入設置 | 5d | 2015-01-14 | 2015-01-19 | 60 | 49d | 0d |  | Y-ダクト据付班（4名） | 40h |
| 62 | 13.7 | （PRM,PR3）設置 | 2d | 2015-01-20 | 2015-01-21 | 61 | 49d |  |  | Y-ダクト据付班（4名） | 16h |
| 63 | 13.8 | (IXA,IXC,Gvitmx)墨出し | 2d | 2015-01-06 | 2015-01-07 | 17 | 11d | 0d |  |  |  |
| 64 | 13.9 | コア抜き、カッター | 9d | 2015-01-08 | 2015-01-17 | 63 | 11d | 0d |  |  |  |
| 65 | 13.10 | 土間仕上げ(IXA,IXC,Gvitmx) | 6d | 2015-01-19 | 2015-01-24 | 64 | 11d | 0d |  |  |  |
| 66 | 13.11 | 搬出準備 | 1d? | 2015-01-24 | 2015-01-24 | 67SS-1d | 46d |  |  |  |  |
| 67 | 13.12 | (IXV)搬入設置 | 1d | 2015-01-26 | 2015-01-26 | 65 | 11d | 0d |  | X-ダクト据付班（4名） | 8h |
| 68 | 13.13 | (IXA,IXC,Gvitmx)搬入設置 | 5d | 2015-01-27 | 2015-01-31 | 67 | 11d | 0d |  | X-ダクト据付班（4名） | 40h |
| 69 | 13.14 | （Gvbsy,GVbsx,BS,PR2,SR2,SR3,SRM）墨出し | 3d | 2015-02-02 | 2015-02-04 | 92, 87, 105, 68 | 11d | 0d |  | X-測量・墨出し班 | 24h |
| 70 | 13.15 | コア抜き、カッター | 9d | 2015-02-05 | 2015-02-14 | 69 | 11d | 0d |  |  |  |
| 71 | 13.16 | 土間仕上げ（Gvbsy,GVbsx,BS,PR2,SR2,SR3,SRM） | 11d | 2015-02-16 | 2015-02-27 | 70 | 11d | 0d | finish no earlier than 2014-11-17 | X-土木班 | 88h |
| 72 | 13.17 | （Gvbsy,GVbsx,BS,PR2,SR2,SR3,SRM）設置 | 6d | 2015-02-28 | 2015-03-06 | 71 | 11d | 0d |  | X-ダクト締結班（3名×2班） | 48h |
| 73 | 14 | **中央実験室電気工事** | 10d | 2014-09-16 | 2014-09-27 |  | 141d |  |  |  | 88h |
| 74 | 14.1 | 高圧受電盤設置(1基) | 2d | 2014-09-16 | 2014-09-17 | 87, 92, 105 | 141d | 0d |  | X-運搬据付(5名); Y-運搬据付(5名) | 32h |
| 75 | 14.2 | 高圧ケーブル（CET）配線 | 2d | 2014-09-18 | 2014-09-19 | 74 | 141d | 0d |  |  |  |
| 76 | 14.3 | 動力配線 | 2d | 2014-09-20 | 2014-09-22 | 75 | 141d | 0d |  | X-低圧配線(8名) | 16h |
| 77 | 14.4 | 光ケーブル配線 | 1d | 2014-09-24 | 2014-09-24 | 76 | 141d | 0d |  | X-光（5名) | 8h |
| 78 | 14.5 | 実験盤、手元開閉器、光BOX設置 | 1d | 2014-09-25 | 2014-09-25 | 77 | 141d | 0d |  | X-取付(3名) | 8h |
| 79 | 14.6 | スコットトランス設置 | 1d | 2014-09-26 | 2014-09-26 | 78 | 142d |  | finish no earlier than 2014-09-08 | X-Tr(3名) | 8h |
| 80 | 14.7 | 照明配線 | 2d | 2014-09-26 | 2014-09-27 | 78 | 141d |  | finish no earlier than 2014-09-17 | X-照明(6名) | 16h |

| ID | WBS | Task | Duration | Start | Finish | Predecessors | Total slack | Free slack | Constraint | Calendar |
| --- | --- | --- | --- | --- | --- | --- | --- | --- | --- | --- |
| 81 | 15 | **鹿島建設殿工事** | 189d | 2014-04-01 | 2014-11-21 |  | 95d |  |  |  |
| 82 | 15.1 | Yend排水竪穴 | 14d | 2014-07-10 | 2014-07-26 |  | 77d | 14d | start no earlier than 2014-07-10 |  |
| 83 | 15.2 | アプローチトンネル床コン | 5d | 2014-07-17 | 2014-07-23 |  | 17d | 0d | start no earlier than 2014-07-17 |  |
| 84 | 15.3 | **床コンクリート（測点敷設含む）** | 108d | 2014-04-26 | 2014-09-10 |  | 86d |  |  |  |
| 85 | 15.3.1 | Xアーム | 49d | 2014-07-24 | 2014-09-10 | 83 | 20d | 5d | start no earlier than 2014-07-18 | 24時間体制 |
| 86 | 15.3.2 | Yアーム | 76d | 2014-04-26 | 2014-07-10 |  | 133d | 32d | finish no earlier than 2014-07-10 | 24時間体制 |
| 87 | 15.3.3 | 中央実験室 | 20d | 2014-06-12 | 2014-07-01 |  | 227d | 76d | start no earlier than 2014-06-12 | 24時間体制 |
| 88 | 15.3.4 | （先行分）中央実験室 | 1d | 2014-07-23 | 2014-07-23 | 93 | 175d | 0d | start no earlier than 2014-07-17 |  |
| 89 | 15.4 | **防塵工事** | 67d | 2014-06-24 | 2014-09-13 |  | 67d |  |  |  |
| 90 | 15.4.1 | Xエンド室 | 13d | 2014-09-01 | 2014-09-13 |  | 16d | 2d | start no earlier than 2014-09-01 | 24時間体制 |
| 91 | 15.4.2 | Yエンド室 | 30d | 2014-06-24 | 2014-07-23 |  | 84d | 4d | start no earlier than 2014-06-24 | 24時間体制 |
| 92 | 15.4.3 | 中央実験室 | 30d | 2014-07-24 | 2014-08-22 |  | 175d | 24d | start no earlier than 2014-07-24 | 24時間体制 |
| 93 | 15.4.4 | （先行分）中央実験室 | 12d | 2014-07-08 | 2014-07-22 |  | 81d | 0d | start no earlier than 2014-07-08 |  |
| 94 | 15.5 | 扉横断部排水工事 | 50d | 2014-05-20 | 2014-07-08 |  | 254d |  | start no earlier than 2014-05-20 | 24時間体制 |
| 95 | 15.6 | **花崗岩設置工事** | 45d | 2014-07-16 | 2014-09-10 |  | 154d |  |  |  |
| 96 | 15.6.1 | Xアーム | 10d | 2014-09-01 | 2014-09-10 |  | 190d |  | start no earlier than 2014-09-01 | 24時間体制 |
| 97 | 15.6.2 | Yアーム | 10d | 2014-07-16 | 2014-07-25 |  | 237d |  | start no earlier than 2014-07-16 | 24時間体制 |
| 98 | 15.7 | **天井吊りアンカー施工** | 120d | 2014-04-01 | 2014-08-29 |  | 164d |  |  |  |
| 99 | 15.7.1 | Xエンド室 | 10d | 2014-04-12 | 2014-04-21 |  | 332d |  | start no earlier than 2014-04-12 | 24時間体制 |
| 100 | 15.7.2 | Yエンド室 | 8d | 2014-04-01 | 2014-04-08 |  | 345d |  | start no earlier than 2014-04-01 | 24時間体制 |
| 101 | 15.7.3 | 中央実験室 | 23d | 2014-04-20 | 2014-05-12 |  | 311d |  | start no earlier than 2014-04-20 | 24時間体制 |
| 102 | 15.7.4 | 天井クレーン設置 | 15d | 2014-08-15 | 2014-08-29 |  | 202d |  | finish no earlier than 2014-08-29 | 24時間体制 |
| 103 | 15.8 | **中央実験室建築工事** | 122d | 2014-06-24 | 2014-11-20 |  | 96d |  |  |  |
| 104 | 15.8.1 | 間仕切り壁 | 81d | 2014-09-01 | 2014-11-20 |  | 119d |  | start no earlier than 2014-09-01 | 24時間体制 |
| 105 | 15.8.2 | 機械基礎 | 13d | 2014-09-01 | 2014-09-13 |  | 153d | 2d | start no earlier than 2014-09-01 | 24時間体制 |
| 106 | 15.8.3 | （先行分）間仕切り壁 | 12d | 2014-06-24 | 2014-07-07 |  | 188d | 13d | start no earlier than 2014-06-24 |  |
| 107 | 15.8.4 | （先行分）機械基礎 | 6d | 2014-06-24 | 2014-06-30 |  | 194d | 19d | start no earlier than 2014-06-24 |  |
| 108 | 15.8.5 | 螺旋階段 | 6d | 2014-09-01 | 2014-09-06 |  | 194d |  | start no earlier than 2014-09-01 | 24時間体制 |

| ID | WBS | Task | Duration | Start | Finish | Predecessors | Total slack | Free slack | Constraint | Calendar | Work |
| --- | --- | --- | --- | --- | --- | --- | --- | --- | --- | --- | --- |
| 109 | 15.9 | **Xエンド室建築工事** | 35d | 2014-07-17 | 2014-08-30 |  | 48d |  |  |  |  |
| 110 | 15.9.1 | 間仕切り壁 | 45d | 2014-07-17 | 2014-08-30 |  | 201d |  | start no earlier than 2014-07-17 | 24時間体制 |  |
| 111 | 15.9.2 | 機械基礎 | 13d | 2014-07-17 | 2014-07-29 |  | 62d | 48d | start no earlier than 2014-07-17 | 24時間体制 |  |
| 112 | 15.9.3 | 螺旋階段 | 6d | 2014-07-17 | 2014-07-22 |  | 240d |  | start no earlier than 2014-07-17 | 24時間体制 |  |
| 113 | 15.10 | **Yエンド室建築工事** | 32d | 2014-06-26 | 2014-08-02 |  | 113d |  |  |  |  |
| 114 | 15.10.1 | 間仕切り壁 | 38d | 2014-06-26 | 2014-08-02 |  | 229d |  | start no earlier than 2014-06-26 | 24時間体制 |  |
| 115 | 15.10.2 | 機械基礎 | 8d | 2014-06-26 | 2014-07-03 |  | 140d | 39d | start no earlier than 2014-06-26 | 24時間体制 |  |
| 116 | 15.10.3 | 螺旋階段 | 6d | 2014-06-26 | 2014-07-01 |  | 261d |  | start no earlier than 2014-06-26 | 24時間体制 |  |
| 117 | 15.11 | **換気設備** | 130d | 2014-06-15 | 2014-11-21 |  | 95d |  |  |  |  |
| 118 | 15.11.1 | 仮設換気撤去 | 124d | 2014-07-21 | 2014-11-21 |  | 118d |  | start no earlier than 2014-07-21 | 24時間体制 |  |
| 119 | 15.11.2 | 本設工事 | 153d | 2014-06-15 | 2014-11-14 |  | 125d |  | start no earlier than 2014-06-15 | 24時間体制 |  |
| 120 | 16 | **車上渡し物品納入（希望）** | 267d? | 2014-04-01 | 2015-02-27 |  | 17d |  |  |  | 823.2h |
| 121 | 16.1 | IMM | 1d? | 2014-07-28 | 2014-07-28 |  | 189d |  | start no earlier than 2014-07-28 |  |  |
| 122 | 16.2 | IFI | 1d? | 2014-07-28 | 2014-07-28 |  | 189d |  | start no earlier than 2014-07-28 |  |  |
| 123 | 16.3 | MCF | 1d? | 2014-07-28 | 2014-07-28 |  | 189d |  | start no earlier than 2014-07-28 |  |  |
| 124 | 16.4 | MCE | 1d? | 2014-07-28 | 2014-07-28 |  | 189d |  | start no earlier than 2014-07-28 |  |  |
| 125 | 16.5 | EYV | 1d? | 2014-08-11 | 2014-08-11 | 34SS-2d | 177d |  |  |  |  |
| 126 | 16.6 | EYA | 1d? | 2014-08-11 | 2014-08-11 | 34SS-2d | 177d |  |  |  |  |
| 127 | 16.7 | 接続用鏡板 φ1000 | 1d? | 2014-08-11 | 2014-08-11 | 34SS-2d | 177d |  |  |  |  |
| 128 | 16.8 | IYV | 1d? | 2015-01-24 | 2015-01-24 | 67SS-1d | 46d |  |  |  |  |
| 129 | 16.9 | EXV | 1d? | 2014-10-06 | 2014-10-06 | 12SS-1d | 134d |  |  |  |  |
| 130 | 16.10 | IXV | 1d? | 2015-01-24 | 2015-01-24 | 67SS-1d | 46d |  |  |  |  |
| 131 | 16.11 | BS | 1d? | 2015-02-27 | 2015-02-27 | 72SS-1d | 17d |  |  |  |  |
| 132 | 16.12 | SR2 | 1d? | 2015-02-27 | 2015-02-27 | 72SS-1d | 17d |  |  |  |  |
| 133 | 16.13 | SR3 | 1d? | 2015-02-27 | 2015-02-27 | 72SS-1d | 17d |  |  |  |  |
| 134 | 16.14 | SRM | 1d? | 2015-02-27 | 2015-02-27 | 72SS-1d | 17d |  |  |  |  |
| 135 | 16.15 | IYA | 1d? | 2014-10-06 | 2014-10-06 | 12SS-1d | 134d |  |  |  |  |
| 136 | 16.16 | EXA | 1d? | 2014-10-06 | 2014-10-06 | 12SS-1d | 134d |  |  |  |  |
| 137 | 16.17 | IXA | 1d? | 2015-01-24 | 2015-01-24 | 67SS-1d | 46d |  |  |  |  |
| 138 | 16.18 | PR2 | 1d? | 2015-02-27 | 2015-02-27 | 72SS-1d | 17d |  |  |  |  |
| 139 | 16.19 | PR3 | 1d? | 2015-02-27 | 2015-02-27 | 72SS-1d | 17d |  |  |  |  |
| 140 | 16.20 | PRM | 1d? | 2015-02-27 | 2015-02-27 | 72SS-1d | 17d |  |  |  |  |
| 141 | 16.21 | 接続用ダクト φ400 | 1d? | 2014-07-28 | 2014-07-28 |  | 189d |  | start no earlier than 2014-07-28 |  |  |
| 142 | 16.22 | クランプ類、盲フランジ類、ガスケット類 | 1d? | 2014-08-11 | 2014-08-11 | 34SS-2d | 177d |  |  |  |  |
| 143 | 16.23 | 地物用排気ポート付きダクト１ | 1d? | 2014-09-17 | 2014-09-17 | 39SS-1d | 149d |  |  |  |  |
| 144 | 16.24 | 地物用排気ポート付きダクト２ | 1d? | 2014-09-17 | 2014-09-17 | 39SS-1d | 149d |  |  |  |  |
| 145 | 16.25 | 地物用排気ポート付きダクト３ | 1d? | 2014-09-17 | 2014-09-17 | 39SS-1d | 149d |  |  |  |  |
| 146 | 16.26 | 地物用排気ポート付きダクト４ | 1d? | 2014-09-17 | 2014-09-17 | 39SS-1d | 149d |  |  |  |  |
| 147 | 16.27 | 地物用φ400ゲートバルブ | 1d? | 2014-09-17 | 2014-09-17 | 39SS-1d | 149d |  |  |  |  |
| 148 | 16.28 | 地物用ICF253ゲートバルブ | 1d? | 2014-09-17 | 2014-09-17 | 39SS-1d | 149d |  |  |  |  |
| 149 | 16.29 | 地物用ICF253排気フランジ | 1d? | 2014-09-17 | 2014-09-17 | 39SS-1d | 149d |  |  |  |  |
| 150 | 16.30 | 断熱真空設備用超高真空ダクト φ1000架台付き | 1d? | 2015-01-24 | 2015-01-24 | 67SS-1d | 46d |  |  |  |  |
| 151 | 16.31 | 輻射シールド付き真空ダクト φ800架台付き | 1d? | 2015-01-24 | 2015-01-24 | 67SS-1d | 46d |  |  |  |  |

| ID | WBS | Task | Type | Duration | Start | Finish | Predecessors | Total slack | Free slack | Constraint | Resources | Work |
| --- | --- | --- | --- | --- | --- | --- | --- | --- | --- | --- | --- | --- |
| 154 | 16.32 | **断熱真空設備搬入・架台交換等** |  | 5d? | 2014-11-05 | 2014-11-10 |  | 91.5d |  |  |  | 64h |
| 155 | 16.32.1 | 断熱真空設備中央室搬入・一時保管 |  | 1d | 2014-11-05 | 2014-11-05 |  | 91.5d | 0d | finish no earlier than 2014-11-05 | ICRR立ち会い１名; 中央室クレーン(作業員２名作業日１日) | 16h |
| 156 | 16.32.2 | 断熱真空設備架台交換 |  | 1d? | 2014-11-06 | 2014-11-06 | 155 | 91.5d | 0d |  | 中央室クレーン(作業員２名); ICRR立ち会い１名 | 16h |
| 157 | 16.32.3 | 断熱真空設備Y-end室搬入 |  | 1d? | 2014-11-07 | 2014-11-07 | 156 | 91.5d | 0d |  | Y-運搬据付(5名) [50%]; ICRR立ち会い１名 [50%] | 8h |
| 158 | 16.32.4 | 断熱真空設備X-end室搬入 |  | 2d? | 2014-11-08 | 2014-11-10 | 157 | 104d | 59d |  | X-運搬据付(5名) [50%]; ICRR立ち会い１名 | 24h |
| 159 | 16.33 | **エンド室クライオスタット組み立て** |  | 60.5d? | 2014-11-24 | 2015-02-09 |  | 0d |  |  |  | 759.2h |
| 160 | 16.33.1 | エンド室クライオスタット組み立て | milestone | 0d? | 2014-11-24 | 2014-11-24 |  | 0d |  | must start on 2014-11-24 |  |  |
| 161 | 200 | **Y-エンド側クライオスタット組み立て** |  | 60.5d? | 2014-11-24 | 2015-02-09 | 35, 42 | 0d |  |  |  | 759.2h |
| 162 | 16.33.2.1 | Y-エンド側クライオスタット組み立て | milestone | 0d? | 2014-11-24 | 2014-11-24 |  | 0d |  | must start on 2014-11-24 |  |  |
| 163 | 200 | 乗り込みと現地段取り |  | 0.5d | 2014-11-24 | 2014-11-24 | 35, 42 | 64.1d | 0.5d | start no earlier than 2014-11-24 | クライオ組立班(3名体制) | 4h |
| 164 | 16.33.2.3 | 簡易空調装置の据付・接続(電源含む) |  | 1d | 2014-11-25 | 2014-11-25 | 163 | 63.6d | 0.5d | start no earlier than 2014-11-25 |  |  |
| 165 | 16.33.2.4 | 木箱梱包解体 |  | 0.5d | 2014-11-26 | 2014-11-26 | 163 | 63.1d | 0d | start no earlier than 2014-11-26 | クライオ組立班(3名体制) | 4h |
| 166 | 16.33.2.5 | 作業用足場の一部設置 |  | 0.5d | 2014-11-26 | 2014-11-26 | 165, 164 | 63.1d | 0d | start no earlier than 2014-11-25 | クライオ組立班(3名体制); カニクレーン班（オペレータ1名+玉掛け1名） | 8h |
| 167 | 16.33.2.6 | 片側面大口径仮フランジNo.1の取り外し |  | 0.5d | 2014-11-27 | 2014-11-27 | 166 | 63.1d | 0d |  | カニクレーン班（オペレータ1名+玉掛け1名）; クライオ組立班(2名体制) | 8h |
| 168 | 16.33.2.7 | 側面フランジNo.1養生 |  | 0.2d | 2014-11-27 | 2014-11-27 | 167 | 63.1d | 0d |  | クライオ組立班(2名体制) | 1.6h |
| 169 | 16.33.2.8 | 片側面大口径仮フランジNo.2の取り外し |  | 0.5d | 2014-11-27 | 2014-11-28 | 168 | 87.6d | 0d |  | カニクレーン班（オペレータ1名+玉掛け1名）; クライオ組立班(4名体制) | 8h |
| 170 | 16.33.2.9 | 側面フランジNo.2養生 |  | 0.2d | 2014-11-28 | 2014-11-28 | 169 | 87.6d | 0d |  | クライオ組立班(2名体制) | 1.6h |
| 171 | 16.33.2.10 | 簡易防塵室の設置 |  | 2d | 2014-11-28 | 2014-12-01 | 168, 170, 166 | 87.6d |  |  |  |  |
| 172 | 16.33.2.11 | 上部大口径仮フランジの取り外し |  | 0.5d | 2014-12-01 | 2014-12-01 | 168 | 60.8d | 0d | start no earlier than 2014-12-01 | カニクレーン班（オペレータ1名+玉掛け1名） [66.7%]; クライオ組立班(2名体制) [66.7%]; 東芝技術指導(1名体制) [66.7%] | 8h |
| 173 | 16.33.2.12 | 上部大口径仮フランジの養生 |  | 0.2d | 2014-12-01 | 2014-12-01 | 172 | 60.8d | 0.3d | start no earlier than 2014-09-17 | クライオ組立班(2名体制); 東芝技術指導(1名体制) | 3.2h |
| 174 | 16.33.2.13 | 上部大口径仮フランジーシールド感輸送用固定治具の取り外し |  | 1d | 2014-12-02 | 2014-12-02 | 173 | 60.5d | 0d | start no earlier than 2014-12-02 | クライオ組立班(2名体制); カニクレーン班（オペレータ1名+玉掛け1名）; 東芝技術指導(1名体制) | 24h |
| 175 | 16.33.2.14 | 上部輻射シールド部品の取り付け |  | 2d | 2014-12-03 | 2014-12-04 | 174 | 60.5d | 0d | finish no earlier than 2014-09-23 | カニクレーン班（オペレータ1名+玉掛け1名） | 16h |
| 176 | 16.33.2.15 | 上部大口径フランジの取り出し |  | 0.5d | 2014-12-05 | 2014-12-05 | 175 | 60.5d | 0d | finish no earlier than 2014-04-01 | カニクレーン班（オペレータ1名+玉掛け1名）; クライオ組立班(2名体制); 東芝技術指導(2名体制) | 12h |
| 177 | 16.33.2.16 | 上部大口径フランジ用金属ガスケットの準備と治具装着 <-予行練習 |  | 0.5d | 2014-12-05 | 2014-12-05 | 176 | 60.5d | 0d | finish no earlier than 2014-04-01 | カニクレーン班（オペレータ1名+玉掛け1名）; クライオ組立班(2名体制); 東芝技術指導(2名体制) | 12h |
| 178 | 16.33.2.17 | 上部大口径フランジ用金属ガスケットの準備と治具装着 <-本番 |  | 0.5d | 2014-12-06 | 2014-12-06 | 177 | 60.5d | 0d |  | カニクレーン班（オペレータ1名+玉掛け1名）; クライオ組立班(2名体制); 東芝技術指導(2名体制) | 12h |
| 179 | 16.33.2.18 | 上部大口径フランジの据え付けとボルト締め込み <- 本番 |  | 0.5d | 2014-12-06 | 2014-12-06 | 178 | 60.5d | 1d |  | カニクレーン班（オペレータ1名+玉掛け1名）; クライオ組立班(2名体制); 東芝技術指導(2名体制) | 12h |
| 180 | 16.33.2.19 | 側面大口径フランジNo.1の取り出し |  | 0.5d | 2014-12-09 | 2014-12-09 | 179 | 59.5d | 0d | start no earlier than 2014-12-09 | カニクレーン班（オペレータ1名+玉掛け1名）; クライオ組立班(2名体制); 東芝技術指導(2名体制) | 12h |
| 181 | 16.33.2.20 | 側面大口径フランジNo.1用エラストマーガスケット取付・フランジ取り付け |  | 0.5d | 2014-12-09 | 2014-12-09 | 180 | 59.5d | 0d | finish no earlier than 2014-09-23 | カニクレーン班（オペレータ1名+玉掛け1名）; クライオ組立班(2名体制); 東芝技術指導(2名体制) | 12h |
| 182 | 16.33.2.21 | Y-end-クライオスタット冷凍機ユニット据え付けと接続 |  | 4d | 2014-12-10 | 2014-12-13 | 181 | 59.5d | 0d | start no earlier than 2014-12-09 | カニクレーン班（オペレータ1名+玉掛け1名）; クライオ組立班(2名体制); 東芝技術指導初日のみ; ジェック東理社技術指導(1名体制) | 128h |
| 183 | 16.33.2.22 | 側面大口径フランジNo.2の取り出し |  | 0.5d | 2014-12-15 | 2014-12-15 | 182 | 59.5d | 0d | start no earlier than 2014-09-17 | カニクレーン班（オペレータ1名+玉掛け1名）; クライオ組立班(2名体制) | 8h |
| 184 | 16.33.2.23 | 側面大口径フランジNo.2用エラストマーガスケット取付・フランジ取り付け |  | 0.5d | 2014-12-15 | 2014-12-15 | 183 | 59.5d | 0d | finish no earlier than 2014-09-23 | カニクレーン班（オペレータ1名+玉掛け1名）; クライオ組立班(2名体制) | 8h |
| 185 | 16.33.2.24 | BRT側断熱真空設備部品追加 |  | 0.5d | 2014-12-16 | 2014-12-16 | 184, 157 | 59.5d | 0d | start no earlier than 2014-12-15 | クライオ組立班(2名体制) | 4h |
| 186 | 16.33.2.25 | クライオオスタットBRT側ビームポート開口と養生 |  | 0.5d | 2014-12-16 | 2014-12-16 | 185 | 59.5d | 0d |  | クライオ組立班(2名体制) | 4h |
| 187 | 16.33.2.26 | BRT側断熱真空設備据え付け並びに接続作業 |  | 1.5d | 2014-12-17 | 2014-12-18 | 186 | 59.5d | 0d |  | クライオ組立班(4名体制) | 12h |
| 188 | 16.33.2.27 | 断熱真空設備冷凍機据え付けと接続 |  | 1d | 2014-12-18 | 2014-12-19 | 187 | 59.5d | 0d |  | クライオ組立班(2名体制); ジェック東理社技術指導(1名体制) | 16h |
| 189 | 16.33.2.28 | ヘリウムリークデテクター及び真空排気装置の接続 |  | 1d | 2014-12-19 | 2014-12-20 | 188 | 59.5d | 0d | start no earlier than 2014-09-17 | クライオ組立班(2名体制) | 8h |
| 190 | 16.33.2.29 | 真空引き |  | 9d | 2014-12-20 | 2015-01-07 | 189 | 59.5d | 0d |  | リーク試験担当（ICRR担当2名） | 72h |
| 191 | 16.33.2.30 | 簡易防塵室と簡易空調装置の解体と撤去移動 |  | 1d | 2014-12-19 | 2014-12-20 | 188 | 68.5d | 0.5d | finish no earlier than 2014-04-01 | クライオ組立班(2名体制) | 8h |
| 192 | 16.33.2.31 | ヘリウムリーク試験 |  | 2d | 2015-01-07 | 2015-01-09 | 190 | 59.5d |  | start no earlier than 2015-01-05 | リーク試験担当（ICRR担当2名） | 16h |

| ID | WBS | Task | Duration | Start | Finish | Predecessors | Total slack | Free slack | Constraint | Resources | Work |
| --- | --- | --- | --- | --- | --- | --- | --- | --- | --- | --- | --- |
| 193 | 16.33.2.32 | **X-endクライオスタット組み立て** | 36.5d? | 2014-12-22 | 2015-02-09 |  | 33.5d |  |  |  | 316.8h |
| 194 | 200 | 乗り込みと現地段取り | 0.5d | 2014-12-22 | 2014-12-22 | 191, 189 | 68d | 0d | start no earlier than 2014-12-22 | クライオ組立班(4名体制) | 4h |
| 195 | 16.33.2.32.2 | 簡易空調装置の据付・接続(電源含む) | 1d? | 2014-12-22 | 2014-12-23 | 194 | 68d | 0d |  |  |  |
| 196 | 16.33.2.32.3 | 作業用足場の一部設置 | 0.5d | 2014-12-23 | 2014-12-23 | 195 | 68d |  | start no earlier than 2014-09-16 | クライオ組立班(3名体制) | 4h |
| 197 | 16.33.2.32.4 | 片側面大口径仮フランジNo.1の取り外し | 0.5d | 2015-01-06 | 2015-01-06 |  | 53.9d | 0d | start no earlier than 2015-01-06 | カニクレーン班（オペレータ1名+玉掛け1名）; クライオ組立班(2名体制) | 8h |
| 198 | 16.33.2.32.5 | 側面フランジNo.1養生 | 0.2d | 2015-01-06 | 2015-01-06 | 197 | 53.9d | 0d |  | クライオ組立班(2名体制) | 1.6h |
| 199 | 16.33.2.32.6 | 片側面大口径仮フランジNo.2の取り外し | 0.5d | 2015-01-06 | 2015-01-07 | 198 | 53.9d | 0d |  | カニクレーン班（オペレータ1名+玉掛け1名）; クライオ組立班(4名体制) | 8h |
| 200 | 16.33.2.32.7 | 側面フランジNo.2養生 | 0.2d | 2015-01-07 | 2015-01-07 | 199 | 53.9d | 0d |  | クライオ組立班(2名体制) | 1.6h |
| 201 | 16.33.2.32.8 | 簡易防塵室の設置 | 2d | 2015-01-07 | 2015-01-09 | 198, 200 | 53.9d | 0d |  |  |  |
| 202 | 16.33.2.32.9 | 作業予備日 | 1d? | 2015-01-09 | 2015-01-10 | 201 | 58.6d |  |  |  |  |
| 203 | 16.33.2.32.10 | 上部大口径仮フランジの取り外し | 0.5d | 2015-01-12 | 2015-01-12 | 201 | 52.3d | 0d | start no earlier than 2015-01-12 | カニクレーン班（オペレータ1名+玉掛け1名）; クライオ組立班(2名体制) | 8h |
| 204 | 16.33.2.32.11 | 上部大口径仮フランジの養生 | 0.2d | 2015-01-12 | 2015-01-12 | 203 | 52.3d | 0d | start no earlier than 2014-09-17 | クライオ組立班(2名体制) | 1.6h |
| 205 | 16.33.2.32.12 | 上部大口径仮フランジーシールド間輸送用固定治具取り外し | 1d | 2015-01-12 | 2015-01-13 | 204 | 52.3d | 0d |  | クライオ組立班(2名体制); カニクレーン班（オペレータ1名+玉掛け1名） | 16h |
| 206 | 16.33.2.32.13 | 上部輻射シールド部品の取り付け | 2d | 2015-01-13 | 2015-01-15 | 205 | 52.3d | 0d | start no earlier than 2015-01-12 | カニクレーン班（オペレータ1名+玉掛け1名） | 16h |
| 207 | 16.33.2.32.14 | 上部大口径フランジの取り出し | 0.5d | 2015-01-15 | 2015-01-16 | 206 | 52.3d | 0d | finish no earlier than 2014-04-01 | カニクレーン班（オペレータ1名+玉掛け1名）; クライオ組立班(2名体制) | 8h |
| 208 | 16.33.2.32.15 | 上部大口径フランジ用金属ガスケットの準備と治具装着 <-予行練習 | 0.5d | 2015-01-16 | 2015-01-16 | 207 | 52.3d | 0d | finish no earlier than 2014-04-01 | カニクレーン班（オペレータ1名+玉掛け1名）; クライオ組立班(2名体制) | 8h |
| 209 | 16.33.2.32.16 | 上部大口径フランジ用金属ガスケットの準備と治具装着 <-本番 | 0.5d | 2015-01-16 | 2015-01-17 | 208 | 52.3d | 0d |  | カニクレーン班（オペレータ1名+玉掛け1名）; クライオ組立班(2名体制) | 8h |
| 210 | 16.33.2.32.17 | 上部大口径フランジの据え付けとボルト締め込み <- 本番 | 0.5d | 2015-01-17 | 2015-01-17 | 209 | 52.3d |  |  | カニクレーン班（オペレータ1名+玉掛け1名）; クライオ組立班(2名体制) | 8h |
| 211 | 16.33.2.32.18 | X-end-クライオスタット冷凍機ユニット据え付けと接続 | 4d | 2015-01-19 | 2015-01-22 |  | 45d | 0d | start no earlier than 2015-01-19 | カニクレーン班（オペレータ1名+玉掛け1名）; クライオ組立班(2名体制) | 64h |
| 212 | 16.33.2.32.19 | 側面大口径フランジNo.1の取り出し | 0.5d | 2015-01-23 | 2015-01-23 | 211 | 45d | 0d | start no earlier than 2014-12-08 | カニクレーン班（オペレータ1名+玉掛け1名）; クライオ組立班(2名体制) | 8h |
| 213 | 16.33.2.32.20 | 側面大口径フランジNo.1用エラストマーガスケット取付・フランジ取り付け | 0.5d | 2015-01-23 | 2015-01-23 | 212 | 45d | 0d | finish no earlier than 2014-09-23 | クライオ組立班(2名体制) | 4h |
| 214 | 16.33.2.32.21 | 側面大口径フランジNo.2の取り出し | 0.5d | 2015-01-24 | 2015-01-24 | 213 | 45d | 0d | start no earlier than 2014-09-17 | カニクレーン班（オペレータ1名+玉掛け1名）; クライオ組立班(2名体制) | 8h |
| 215 | 16.33.2.32.22 | 側面大口径フランジNo.2用エラストマーガスケット取付・フランジ取り付け | 0.5d | 2015-01-24 | 2015-01-24 | 214 | 45d | 0d | finish no earlier than 2014-09-23 | クライオ組立班(2名体制) | 4h |
| 216 | 16.33.2.32.23 | BRT側断熱真空設備部品追加 | 0.5d | 2015-01-26 | 2015-01-26 | 215, 158 | 45d | 0d | start no earlier than 2014-12-15 | クライオ組立班(2名体制) | 4h |
| 217 | 16.33.2.32.24 | クライオオスタットBRT側ビームポート開口と養生 | 0.5d | 2015-01-26 | 2015-01-26 | 216 | 45d |  |  | クライオ組立班(2名体制) | 4h |
| 218 | 16.33.2.32.25 | BRT側断熱真空設備据え付け並びに接続作業 | 1.5d | 2015-01-26 | 2015-01-27 |  | 33.5d | 0d | start no earlier than 2015-01-26 | クライオ組立班(4名体制); カニクレーン班（オペレータ1名+玉掛け1名） | 24h |
| 219 | 16.33.2.32.26 | 断熱真空設備冷凍機据え付けと接続 | 1d | 2015-01-27 | 2015-01-28 | 218 | 33.5d | 0d |  | クライオ組立班(2名体制) | 8h |
| 220 | 16.33.2.32.27 | ヘリウムリークデテクター及び真空排気装置の接続 | 1d | 2015-01-28 | 2015-01-29 | 219 | 33.5d | 0d | start no earlier than 2014-09-17 | クライオ組立班(2名体制) | 8h |
| 221 | 16.33.2.32.28 | 真空引き | 7d | 2015-01-29 | 2015-02-06 | 220 | 35d | 0d | finish no earlier than 2015-01-05 | リーク試験担当（ICRR担当2名） | 56h |
| 222 | 16.33.2.32.29 | 簡易空調装置と簡易防塵室の解体 | 0.5d | 2015-02-06 | 2015-02-06 | 221 | 35d |  | finish no earlier than 2014-04-01 | クライオ組立班(4名体制); クライオ組立班(3名体制) | 8h |
| 223 | 16.33.2.32.30 | ヘリウムリーク試験 | 2d | 2015-02-06 | 2015-02-09 | 220FS+7d | 33.5d |  | start no earlier than 2015-01-05 | リーク試験担当（ICRR担当2名） | 16h |
